# 110 Grange Rd

Schedule from MS Project, 2016-02-16 to 2016-05-24, costs in $.
Watsonia Software Pty Ltd

## Calendars

- Standard: Mon-Fri 08:00-12:00, 13:00-17:00; Sat-Sun off.

## Resources

| Resource | Rate |
| --- | --- |
| Draftsperson | 40 |
| Electrician | 33 |
| Plumber | 35 |
| Concreter | 18 |
| Carpenter | 19 |
| Labourer | 12 |
| Painter | 14 |
| Supervisor | 28 |
| Back Hoe & Operator | 85 |
| Cabinet Maker | 20.5 |
| Roof Tiler | 15 |
| Bricklayer | 13 |
| Plasterer | 14 |

## Schedule

| ID | WBS | Task | Type | Duration | Start | Finish | Predecessors | Total slack | Resources | Work | Cost |
| --- | --- | --- | --- | --- | --- | --- | --- | --- | --- | --- | --- |
| 1 | 1 | **Plans and Site** |  | 29d | 2016-02-16 | 2016-03-25 |  | 0d |  | 384h | 6,808 |
| 2 | 1.1 | Create Site Plans |  | 3d | 2016-02-16 | 2016-02-18 |  | 0d | Draftsperson | 24h | 960 |
| 3 | 1.2 | Arrange Council Permits |  | 1d | 2016-02-19 | 2016-02-19 | 2 | 0d | Draftsperson | 8h | 320 |
| 4 | 1.3 | Prepare Site |  | 5d | 2016-03-11 | 2016-03-17 | 3FS+14d | 0d | Labourer [300%]; Carpenter | 160h | 2,200 |
| 5 | 1.4 | Organise Materials |  | 1d | 2016-03-11 | 2016-03-11 | 4SS | 52d | Supervisor | 8h | 224 |
| 6 | 1.5 | Lay Foundations |  | 3d | 2016-03-18 | 2016-03-22 | 4 | 0d | Concreter; Carpenter; Labourer [200%] | 96h | 1,464 |
| 7 | 1.6 | Plumbing for Sewerage |  | 1d | 2016-03-23 | 2016-03-23 | 6 | 0d | Plumber | 8h | 280 |
| 8 | 1.7 | Pour Slab |  | 2d | 2016-03-24 | 2016-03-25 | 7 | 0d | Concreter [300%]; Carpenter; Labourer | 80h | 1,360 |
| 9 | 1.8 | Foundations Complete | milestone | 0d | 2016-03-25 | 2016-03-25 | 8 | 0d |  |  |  |
| 10 | 2 | **To Lock Up** |  | 18d | 2016-03-28 | 2016-04-20 | 9 | 0d |  | 512h | 7,712 |
| 11 | 2.1 | Erect Framing |  | 3d | 2016-03-28 | 2016-03-30 |  | 0d | Carpenter [400%] | 96h | 1,824 |
| 12 | 2.2 | Lay Roofing |  | 6d | 2016-03-31 | 2016-04-07 | 11 | 0d | Roof Tiler [200%]; Labourer [200%] | 192h | 2,592 |
| 13 | 2.3 | Brick Walls |  | 5d | 2016-04-08 | 2016-04-14 | 12 | 0d | Bricklayer [400%] | 160h | 2,080 |
| 14 | 2.4 | Fit Windows & Doors |  | 4d | 2016-04-15 | 2016-04-20 | 13 | 0d | Carpenter [200%] | 64h | 1,216 |
| 15 | 2.5 | Lockup | milestone | 0d | 2016-04-20 | 2016-04-20 | 14 | 0d |  |  |  |
| 16 | 3 | **Fit Out** |  | 24d | 2016-04-21 | 2016-05-24 | 15 | 0d |  | 512h | 9,368 |
| 17 | 3.1 | Electrical Cables |  | 1d | 2016-04-21 | 2016-04-21 |  | 0d | Electrician | 8h | 264 |
| 18 | 3.2 | Internal Plumbing |  | 2d | 2016-04-21 | 2016-04-22 | 17SS | 0d | Plumber | 16h | 560 |
| 19 | 3.3 | Plaster Walls |  | 8d | 2016-04-25 | 2016-05-04 | 18 | 0d | Plasterer [300%] | 192h | 2,688 |
| 20 | 3.4 | Internal Doors and Trim |  | 4d | 2016-05-05 | 2016-05-10 | 19 | 0d | Carpenter [200%] | 64h | 1,216 |
| 21 | 3.5 | Install Kitchen |  | 3d | 2016-05-11 | 2016-05-13 | 20 | 0d | Cabinet Maker [200%] | 48h | 984 |
| 22 | 3.6 | Install Bathroom |  | 2d | 2016-05-11 | 2016-05-12 | 21SS | 0d | Cabinet Maker; Plumber | 32h | 888 |
| 23 | 3.7 | Final Electrical Fittings |  | 2d | 2016-05-13 | 2016-05-16 | 22 | 0d | Electrician | 16h | 528 |
| 24 | 3.8 | Final Plumbing Fittings |  | 2d | 2016-05-13 | 2016-05-16 | 23SS | 0d | Plumber | 16h | 560 |
| 25 | 3.9 | Paint |  | 5d | 2016-05-17 | 2016-05-23 | 24 | 0d | Painter [300%] | 120h | 1,680 |
| 26 | 3.10 | Council Approval |  | 1d | 2016-05-24 | 2016-05-24 | 25 | 0d |  |  |  |
| 27 | 3.11 | Construction Completed | milestone | 0d | 2016-05-24 | 2016-05-24 | 26 | 0d |  |  |  |
