# Work Contouring 2

Schedule from MS Project, 2019-03-01 to 2019-08-27, costs in $.
Microsoft

## Calendars

- Standard: Mon-Fri 08:00-12:00, 13:00-17:00; Sat-Sun off.

## Resources

| Resource | Unit | Rate | Cost per use |
| --- | --- | --- | --- |
| Concrete contractor |  | 80 |  |
| Finish carpentry contractor |  | 60 |  |
| Fencing contractor |  | 65 |  |
| Masonry contractor |  | 60 |  |
| General contractor |  | 50 |  |
| Architect |  | 120 |  |
| Owner |  |  |  |
| Mortgage lender |  |  |  |
| Inspector |  |  |  |
| Electric company |  | 150 |  |
| Site excavation contractor |  | 90 |  |
| Electric contractor |  | 80 |  |
| Plumbing contractor |  | 80 |  |
| Framing contractor |  | 60 |  |
| Roofing contractor |  | 65 |  |
| Heating and AC contractor |  | 65 |  |
| Insulation contractor |  | 60 |  |
| Drywall contractor |  | 60 |  |
| Painting contractor |  | 65 |  |
| Flooring contractor |  | 70 |  |
| Appliance contractor |  | 55 |  |
| Landscape contractor |  | 60 |  |
| Maid service |  | 45 | 90 |
| Paint | Litres | 20 |  |
| Carpet | Sq Metres | 80 | 200 |
| Permit |  |  |  |

## Schedule

| ID | WBS | Task | Type | Duration | Start | Finish | Predecessors | Total slack | Free slack | Resources | Work | Cost |
| --- | --- | --- | --- | --- | --- | --- | --- | --- | --- | --- | --- | --- |
| 1 | 1 | **General Conditions** |  | 26d | 2019-03-01 | 2019-04-05 |  | 0.12d |  |  | 180.8h | 22,610 |
| 2 | 1.1 | Complete plans and develop estimate with owner, architect |  | 5w | 2019-03-01 | 2019-04-04 |  | 0.12d | 0d | General contractor [50%]; Architect [50%]; Owner [12%]; Mortgage lender [12%] | 148.8h | 12,000 |
| 3 | 1.2 | Sign contract and notice to proceed |  | 1d | 2019-04-05 | 2019-04-05 | 2 | 0.12d | 0d | General contractor; Architect; Owner; Mortgage lender | 32h | 1,360 |
| 4 | 1.3 | **Apply for Permits** |  | 0d | 2019-04-05 | 2019-04-05 |  | 0.12d |  |  |  | 9,250 |
| 5 | 1.3.1 | Secure foundaton permit | milestone | 0d | 2019-04-05 | 2019-04-05 | 3 | 0.12d | 0d | General contractor; Permit |  | 2,000 |
| 6 | 1.3.2 | Secure framing permit | milestone | 0d | 2019-04-05 | 2019-04-05 | 3 | 0.12d | 0d | General contractor; Permit |  | 500 |
| 7 | 1.3.3 | Secure electrical permit | milestone | 0d | 2019-04-05 | 2019-04-05 | 3 | 0.12d | 0d | General contractor; Permit |  | 1,000 |
| 8 | 1.3.4 | Secure plumbing permit | milestone | 0d | 2019-04-05 | 2019-04-05 | 3 | 0.12d | 0d | General contractor; Permit |  | 750 |
| 9 | 1.3.5 | Secure HVAC permit | milestone | 0d | 2019-04-05 | 2019-04-05 | 3 | 0.12d | 0d | General contractor; Permit |  | 2,000 |
| 10 | 1.3.6 | Secure miscellaneous permits | milestone | 0d | 2019-04-05 | 2019-04-05 | 3 | 0.12d | 0d | General contractor; Permit |  | 3,000 |
| 11 | 2 | **Site Work** |  | 2.75d | 2019-04-08 | 2019-04-10 |  | 0.12d |  |  | 30h | 2,900 |
| 12 | 2.1 | Clear site |  | 1d | 2019-04-08 | 2019-04-08 | 5, 6, 7, 8, 9, 10 | 0.12d | 0d | Site excavation contractor | 8h | 720 |
| 13 | 2.2 | Install temporary power service |  | 6h | 2019-04-09 | 2019-04-09 | 12 | 0.12d | 0d | Electric company | 6h | 900 |
| 14 | 2.3 | Install underground utilities |  | 1d | 2019-04-09 | 2019-04-10 | 13 | 0.12d | 0d | Electric contractor; Plumbing contractor | 16h | 1,280 |
| 15 | 3 | **Foundation** |  | 13.25d | 2019-04-10 | 2019-04-29 |  | 0d |  |  | 280h | 28,320 |
| 16 | 3.1 | Excavate for foundations |  | 3d | 2019-04-10 | 2019-04-15 | 14 | 0.12d | 0d | Site excavation contractor | 24h | 2,160 |
| 17 | 3.2 | Form basement walls |  | 13d | 2019-04-15 | 2019-04-19 | 16 | 0d |  | Concrete contractor | 104h | 8,840 |
| 18 | 3.3 | Pour concrete for foundations & basement walls |  | 12d | 2019-04-19 | 2019-04-23 | 17 | 0d |  | Concrete contractor | 96h | 8,160 |
| 19 | 3.4 | Strip basement wall forms |  | 2d | 2019-04-23 | 2019-04-24 | 18 | 0d |  | Concrete contractor | 16h | 1,360 |
| 20 | 3.5 | Waterproof/insulate basement walls |  | 2d | 2019-04-24 | 2019-04-25 | 19 | 0d |  | Concrete contractor | 16h | 1,360 |
| 21 | 3.6 | Perform foundation inspection |  | 1d | 2019-04-25 | 2019-04-25 | 20, 16 | 0d |  | Inspector | 8h | 5,000 |
| 22 | 3.7 | Backfill foundation |  | 2d | 2019-04-26 | 2019-04-29 | 21 | 0d |  | Site excavation contractor | 16h | 1,440 |
| 23 | 4 | **Framing** |  | 21.75d | 2019-04-30 | 2019-05-29 |  | 0d |  |  | 174h | 10,080 |
| 24 | 4.1 | Install 1st floor joists |  | 2d | 2019-04-30 | 2019-05-01 | 22 | 0d |  | Framing contractor | 16h | 960 |
| 25 | 4.2 | Lay 1st floor decking |  | 2d | 2019-05-02 | 2019-05-03 | 24 | 0d |  | Framing contractor | 16h | 960 |
| 26 | 4.3 | Frame 1st floor walls |  | 4d | 2019-05-06 | 2019-05-09 | 25 | 0d |  | Framing contractor | 32h | 1,920 |
| 27 | 4.4 | Frame 1st floor corners |  | 1d | 2019-05-10 | 2019-05-10 | 26 | 0d |  | Framing contractor | 8h | 480 |
| 28 | 4.5 | Install 2nd floor joists |  | 2d | 2019-05-13 | 2019-05-14 | 27 | 0d |  | Framing contractor | 16h | 960 |
| 29 | 4.6 | Frame 2nd floor decking |  | 2d | 2019-05-15 | 2019-05-16 | 28 | 0d |  | Framing contractor | 16h | 960 |
| 30 | 4.7 | Frame 2nd floor walls |  | 3d | 2019-05-17 | 2019-05-21 | 29 | 0d |  | Framing contractor | 24h | 1,440 |
| 31 | 4.8 | Frame 2nd floor corners |  | 2d | 2019-05-22 | 2019-05-23 | 30 | 0d |  | Framing contractor | 16h | 960 |
| 32 | 4.9 | Complete roof framing |  | 3d | 2019-05-24 | 2019-05-28 | 31 | 0d |  | Framing contractor | 24h | 1,440 |
| 33 | 4.10 | Conduct framing inspection |  | 6h | 2019-05-29 | 2019-05-29 | 32 | 0d |  | Inspector | 6h |  |

| ID | WBS | Task | Duration | Start | Finish | Predecessors | Total slack | Free slack | Resources | Work | Cost |
| --- | --- | --- | --- | --- | --- | --- | --- | --- | --- | --- | --- |
| 34 | 5 | **Dry In** | 21.75d | 2019-05-29 | 2019-06-27 |  | 0d |  |  | 152h | 9,240 |
| 35 | 5.1 | Install 1st floor sheathing | 3d | 2019-05-29 | 2019-06-03 | 33 | 0d |  | Framing contractor | 24h | 1,440 |
| 36 | 5.2 | Install 2nd floor sheathing | 3d | 2019-06-03 | 2019-06-06 | 35 | 0d |  | Framing contractor | 24h | 1,440 |
| 37 | 5.3 | Install roof decking | 3d | 2019-05-29 | 2019-05-31 | 32 | 3.75d | 0d | Framing contractor | 24h | 1,440 |
| 38 | 5.4 | Install felt, flashing and shingles | 3d | 2019-06-13 | 2019-06-18 | 46 | 0d |  | Roofing contractor | 24h | 1,560 |
| 39 | 5.5 | Hang 1st floor exterior doors | 1d | 2019-06-18 | 2019-06-19 | 38 | 0d |  | Framing contractor | 8h | 480 |
| 40 | 5.6 | Install 1st floor windows | 3d | 2019-06-19 | 2019-06-24 | 39 | 0d |  | Framing contractor | 24h | 1,440 |
| 41 | 5.7 | Install 2nd floor windows | 3d | 2019-06-24 | 2019-06-27 | 40 | 0d |  | Framing contractor | 24h | 1,440 |
| 42 | 6 | **Exterior Finishes** | 13d | 2019-06-27 | 2019-07-16 |  | 12.25d |  |  | 104h | 6,240 |
| 43 | 6.1 | Complete exterior brick | 2w | 2019-06-27 | 2019-07-11 | 41 | 12.25d | 0d | Masonry contractor | 80h | 4,800 |
| 44 | 6.2 | Complete exterior siding | 3d | 2019-07-11 | 2019-07-16 | 43 | 12.25d | 0d | Framing contractor | 24h | 1,440 |
| 45 | 7 | **Utility Rough-Ins and Complete Concrete** | 13.75d | 2019-06-03 | 2019-06-20 |  | 3.75d |  |  | 224h | 16,040 |
| 46 | 7.1 | Rough-in plumbing | 5d | 2019-06-06 | 2019-06-13 | 37, 36 | 0d |  | Plumbing contractor | 40h | 3,200 |
| 47 | 7.2 | Conduct rough-in plumbing inspection | 1d | 2019-06-13 | 2019-06-14 | 46 | 20d | 0d | Inspector | 8h |  |
| 48 | 7.3 | Place concrete for basement floor | 2w | 2019-06-14 | 2019-06-17 | 47 | 40.25d |  | Concrete contractor | 80h | 6,800 |
| 49 | 7.4 | Rough-in electrical | 5d | 2019-06-06 | 2019-06-13 | 37, 36 | 6d | 0d | Electric contractor | 40h | 3,200 |
| 50 | 7.5 | Conduct rough-in electrical inspection | 1d | 2019-06-13 | 2019-06-14 | 49 | 6d | 0d | Inspector | 8h |  |
| 51 | 7.6 | Rough-in HVAC | 3d | 2019-06-14 | 2019-06-19 | 50 | 6d | 0d | Heating and AC contractor | 24h | 1,560 |
| 52 | 7.7 | Conduct rough-in HVAC inspection | 1d | 2019-06-19 | 2019-06-20 | 51 | 24d |  | Inspector | 8h |  |
| 53 | 7.8 | Rough-in communication - phone, cable, computer, alarm | 2d | 2019-06-03 | 2019-06-04 | 37 | 16.75d |  | Electric contractor | 16h | 1,280 |
| 54 | 8 | **Interior Finishes** | 30d | 2019-06-27 | 2019-08-08 |  | 0d |  |  | 408h | 64,360 |
| 55 | 8.1 | **Insulation** | 11d | 2019-06-27 | 2019-07-12 |  | 0d |  |  | 32h | 1,440 |
| 56 | 8.1.1 | Place wall insulation - 1st floor | 1d | 2019-06-27 | 2019-06-28 | 35, 41, 53, 51, 49, 36 | 0d |  | Insulation contractor | 8h | 480 |
| 57 | 8.1.2 | Place wall insulation - 2nd floor | 1d | 2019-06-28 | 2019-07-01 | 56 | 27d | 3d | Insulation contractor | 8h | 480 |
| 58 | 8.1.3 | Place ceiling insulation - 2nd floor | 1d | 2019-07-10 | 2019-07-11 | 64, 57 | 24d | 0d | Insulation contractor | 8h | 480 |
| 59 | 8.1.4 | Conduct insulation inspection | 1d | 2019-07-11 | 2019-07-12 | 58 | 24d |  | Inspector | 8h |  |

| ID | WBS | Task | Duration | Start | Finish | Predecessors | Total slack | Free slack | Resources | Work | Cost |
| --- | --- | --- | --- | --- | --- | --- | --- | --- | --- | --- | --- |
| 60 | 8.2 | **Drywall** | 9d | 2019-06-28 | 2019-07-11 |  | 0d |  |  | 80h | 4,800 |
| 61 | 8.2.1 | Install drywall - 1st floor walls | 2d | 2019-06-28 | 2019-07-02 | 56 | 0d |  | Drywall contractor | 16h | 960 |
| 62 | 8.2.2 | Install drywall - 1st floor overhead | 2d | 2019-07-02 | 2019-07-04 | 61 | 0d |  | Drywall contractor | 16h | 960 |
| 63 | 8.2.3 | Install drywall 2nd floor walls | 2d | 2019-07-04 | 2019-07-08 | 62, 57 | 24d | 0d | Drywall contractor | 16h | 960 |
| 64 | 8.2.4 | Install drywall 2nd floor overhead | 2d | 2019-07-08 | 2019-07-10 | 63 | 24d | 0d | Drywall contractor | 16h | 960 |
| 65 | 8.2.5 | Tape and float 1st floor drywall | 1d | 2019-07-04 | 2019-07-05 | 62 | 0d |  | Drywall contractor | 8h | 480 |
| 66 | 8.2.6 | Tape and float 2nd floor drywall | 1d | 2019-07-10 | 2019-07-11 | 64, 65 | 32.5d |  | Drywall contractor | 8h | 480 |
| 67 | 8.3 | **Paint and Wallpaper** | 11d | 2019-07-05 | 2019-07-22 |  | 0d |  |  | 72h | 11,680 |
| 68 | 8.3.1 | Texture all except entry and kitchen - 1st floor | 1d | 2019-07-05 | 2019-07-08 | 65 | 0d |  | Painting contractor | 8h | 520 |
| 69 | 8.3.2 | Paint all except entry and kitchen - 1st floor | 1d | 2019-07-08 | 2019-07-09 | 68 | 0d |  | Painting contractor; Paint [100 Litres] | 8h | 2,520 |
| 70 | 8.3.3 | Hang wallpaper entry and kitchen - 1st floor | 1d | 2019-07-09 | 2019-07-10 | 69 | 0d |  | Painting contractor | 8h | 520 |
| 71 | 8.3.4 | Texture all - 2nd floor | 1d | 2019-07-08 | 2019-07-09 | 68 | 33.5d | 0d | Painting contractor | 8h | 520 |
| 72 | 8.3.5 | Paint all - 2nd floor | 1d | 2019-07-09 | 2019-07-10 | 71 | 33.5d |  | Painting contractor; Paint [100 Litres] | 8h | 2,520 |
| 73 | 8.3.6 | Paint exterior siding & trim work | 4d | 2019-07-16 | 2019-07-22 | 44 | 12.25d | 0d | Painting contractor; Paint [150 Litres] | 32h | 5,080 |
| 74 | 8.4 | **Cabinets** | 6d | 2019-07-10 | 2019-07-18 |  | 0d |  |  | 48h | 2,880 |
| 75 | 8.4.1 | Install 1st floor - kitchen cabinets | 2d | 2019-07-10 | 2019-07-12 | 70 | 0d |  | Finish carpentry contractor | 16h | 960 |
| 76 | 8.4.2 | Install 1st floor - master bath and guest cabinets | 1d | 2019-07-12 | 2019-07-15 | 75 | 0d |  | Finish carpentry contractor | 8h | 480 |
| 77 | 8.4.3 | Install 2nd floor - hall bath and private bath cabinets | 1d | 2019-07-15 | 2019-07-16 | 76 | 1d | 0d | Finish carpentry contractor | 8h | 480 |
| 78 | 8.4.4 | Install chair rails, crown moldings, trim | 2d | 2019-07-16 | 2019-07-18 | 77 | 20d |  | Finish carpentry contractor | 16h | 960 |
| 79 | 8.5 | **Finish Plumbing** | 6d | 2019-07-12 | 2019-07-22 |  | 0d |  |  | 48h | 3,200 |
| 80 | 8.5.1 | Complete 1st floor - kitchen plumbing | 1d | 2019-07-12 | 2019-07-15 | 75, 47 | 0d |  | Plumbing contractor | 8h | 640 |
| 81 | 8.5.2 | Complete 1st floor - master bath and guest plumbing | 2d | 2019-07-15 | 2019-07-17 | 80, 76 | 0d |  | Plumbing contractor | 16h | 1,280 |
| 82 | 8.5.3 | Complete 2nd floor - hall bath and private bath plumbing | 2d | 2019-07-17 | 2019-07-19 | 81, 77 | 0d |  | Plumbing contractor | 16h | 1,280 |
| 83 | 8.5.4 | Conduct finish plumbing inspection | 1d | 2019-07-19 | 2019-07-22 | 82 | 0d |  | Inspector | 8h |  |

| ID | WBS | Task | Duration | Start | Finish | Predecessors | Total slack | Free slack | Resources | Work | Cost |
| --- | --- | --- | --- | --- | --- | --- | --- | --- | --- | --- | --- |
| 84 | 8.6 | **Finish Electrical** | 3d | 2019-07-19 | 2019-07-24 |  | 1d |  |  | 40h | 2,560 |
| 85 | 8.6.1 | Complete 1st floor circuits to service panel | 1d | 2019-07-19 | 2019-07-22 | 82, 50 | 3d | 0d | Electric contractor | 8h | 640 |
| 86 | 8.6.2 | Complete 2nd floor circuits to service panel | 1d | 2019-07-22 | 2019-07-23 | 85 | 3d | 0d | Electric contractor | 8h | 640 |
| 87 | 8.6.3 | Conduct finish electrical inspection | 1d | 2019-07-23 | 2019-07-24 | 86 | 3d |  | Inspector | 8h |  |
| 88 | 8.6.4 | Complete communications wiring - phone, cable, computer, alarm | 2d | 2019-07-22 | 2019-07-24 | 83 | 0d |  | Electric contractor | 16h | 1,280 |
| 89 | 8.7 | **Finish HVAC** | 3d | 2019-07-24 | 2019-07-29 |  | 0d |  |  | 24h | 1,040 |
| 90 | 8.7.1 | Complete 1st floor - zone 1 HVAC | 1d | 2019-07-24 | 2019-07-25 | 88, 52 | 0d |  | Heating and AC contractor | 8h | 520 |
| 91 | 8.7.2 | Complete 2nd floor - zone 2 HVAC | 1d | 2019-07-25 | 2019-07-26 | 90 | 0d |  | Heating and AC contractor | 8h | 520 |
| 92 | 8.7.3 | Conduct HVAC inspection | 1d | 2019-07-26 | 2019-07-29 | 91 | 0d |  | Inspector | 8h |  |
| 93 | 8.8 | **Carpet, Tile and Appliances** | 8d | 2019-07-29 | 2019-08-08 |  | 0d |  |  | 64h | 36,760 |
| 94 | 8.8.1 | Tile entry, kitchen and baths | 3d | 2019-07-29 | 2019-08-01 | 87, 92 | 0d |  | Flooring contractor | 24h | 1,680 |
| 95 | 8.8.2 | Carpet 1st floor | 2d | 2019-08-01 | 2019-08-05 | 94 | 0d |  | Flooring contractor; Carpet [200 Sq Metres] | 16h | 17,320 |
| 96 | 8.8.3 | Carpet 2nd floor | 2d | 2019-08-05 | 2019-08-07 | 95 | 0d |  | Flooring contractor; Carpet [200 Sq Metres] | 16h | 17,320 |
| 97 | 8.8.4 | Install appliances | 1d | 2019-08-07 | 2019-08-08 | 96 | 0d |  | Appliance contractor | 8h | 440 |
| 98 | 9 | **Landscaping and Grounds Work** | 18d | 2019-07-22 | 2019-08-15 |  | 0d |  |  | 56h | 3,840 |
| 99 | 9.1 | Pour concrete driveway and sidewalks | 2d | 2019-07-22 | 2019-07-23 | 73 | 12.25d |  | Concrete contractor | 16h | 1,360 |
| 100 | 9.2 | Install backyard fence | 2d | 2019-08-08 | 2019-08-12 | 97, 99 | 0d |  | Fencing contractor | 16h | 1,040 |
| 101 | 9.3 | Sod and complete plantings - front yard | 2d | 2019-08-12 | 2019-08-14 | 100 | 0d |  | Landscape contractor | 16h | 960 |
| 102 | 9.4 | Sod and complete plantings - backyard | 1d | 2019-08-14 | 2019-08-15 | 101 | 0d |  | Landscape contractor | 8h | 480 |
| 103 | 10 | **Final Acceptance** | 7.5d | 2019-08-15 | 2019-08-27 |  | 0d |  |  | 62h | 2,450 |
| 104 | 10.1 | Complete final inspection for certificate of occupancy | 6h | 2019-08-15 | 2019-08-16 | 102, 92, 87, 83, 59, 78, 48 | 0d |  | Inspector | 6h |  |
| 105 | 10.2 | Cleanup for occupancy | 1d | 2019-08-16 | 2019-08-19 | 97, 104 | 0d |  | Maid service | 8h | 450 |
| 106 | 10.3 | Perform final walk-through inspection | 1d | 2019-08-19 | 2019-08-20 | 105 | 0d |  | Owner | 8h |  |
| 107 | 10.4 | Complete punch list items | 5d | 2019-08-20 | 2019-08-27 | 106FS-2.5% | 0d |  | General contractor | 40h | 2,000 |
