# Residential Construction 13

Schedule from MS Project, 2016-09-05 to 2017-02-15, costs in $, A marks actual dates.
Microsoft

## Calendars

- Standard: Mon-Fri 08:00-12:00, 13:00-17:00; Sat-Sun off.

## Resources

| Resource | Unit | Rate | Cost per use |
| --- | --- | --- | --- |
| Concrete contractor |  | 80 |  |
| Finish carpentry contractor |  | 60 |  |
| Fencing contractor |  | 65 |  |
| Masonry contractor |  | 60 |  |
| General contractor |  | 50 |  |
| Architect |  | 120 |  |
| Owner |  |  |  |
| Mortgage lender |  |  |  |
| Inspector |  |  |  |
| Electric company |  | 150 |  |
| Site excavation contractor |  | 90 |  |
| Electric contractor |  | 80 |  |
| Plumbing contractor |  | 80 |  |
| Framing contractor |  | 60 |  |
| Roofing contractor |  | 65 |  |
| Heating and AC contractor |  | 65 |  |
| Insulation contractor |  | 60 |  |
| Drywall contractor |  | 60 |  |
| Painting contractor |  | 65 |  |
| Flooring contractor |  | 70 |  |
| Appliance contractor |  | 55 |  |
| Landscape contractor |  | 60 |  |
| Maid service |  | 45 | 90 |
| Paint | Litres | 20 |  |
| Carpet | Sq Metres | 80 | 200 |
| Permit |  |  |  |

## Schedule

| ID | WBS | Task | Type | Duration | Start | Finish | Predecessors | Complete | Remaining | Baseline start | Baseline finish | Baseline duration | Total slack | Free slack | Deadline | Resources | Work | Actual work | Cost | Baseline cost | Actual cost |
| --- | --- | --- | --- | --- | --- | --- | --- | --- | --- | --- | --- | --- | --- | --- | --- | --- | --- | --- | --- | --- | --- |
| 1 | 1 | **General Conditions** |  | 16d | 2016-09-05 A | 2016-09-26 |  | 33% | 10.75d | 2016-09-05 | 2016-09-26 | 16d | 0.12d |  |  |  | 180.8h | 57.6h | 23,610 | 22,610 | 4,340 |
| 2 | 1.1 | Complete plans and develop estimate with owner, architect |  | 3w | 2016-09-05 A | 2016-09-23 |  | 33% | 2w | 2016-09-05 | 2016-09-23 | 3w | 0.25d | 0d |  | General contractor [50%]; Architect [50%]; Owner [12%]; Mortgage lender [12%] | 148.8h | 49.6h | 12,000 | 12,000 | 4,000 |
| 3 | 1.2 | Sign contract and notice to proceed |  | 1d | 2016-09-26 A | 2016-09-26 | 2 | 25% | 0.75d | 2016-09-26 | 2016-09-26 | 1d | 0.12d | 0d | 2016-09-27 | General contractor; Architect; Owner; Mortgage lender | 32h | 8h | 1,360 | 1,360 | 340 |
| 4 | 1.3 | **Apply for Permits** |  | 0d | 2016-09-26 | 2016-09-26 |  |  |  | 2016-09-26 | 2016-09-26 | 0d | 0.12d |  |  |  |  |  | 10,250 | 9,250 |  |
| 5 | 1.3.1 | Secure foundaton permit | milestone | 0d | 2016-09-26 | 2016-09-26 | 3 |  |  | 2016-09-26 | 2016-09-26 | 0d | 0.12d | 0d |  | General contractor; Permit |  |  | 2,000 | 2,000 |  |
| 6 | 1.3.2 | Secure framing permit | milestone | 0d | 2016-09-26 | 2016-09-26 | 3 |  |  | 2016-09-26 | 2016-09-26 | 0d | 0.12d | 0d |  | General contractor; Permit |  |  | 500 | 500 |  |
| 7 | 1.3.3 | Secure electrical permit | milestone | 0d | 2016-09-26 | 2016-09-26 | 3 |  |  | 2016-09-26 | 2016-09-26 | 0d | 0.12d | 0d |  | General contractor; Permit |  |  | 1,000 | 1,000 |  |
| 8 | 1.3.4 | Secure plumbing permit | milestone | 0d | 2016-09-26 | 2016-09-26 | 3 |  |  | 2016-09-26 | 2016-09-26 | 0d | 0.12d | 0d |  | General contractor; Permit |  |  | 750 | 750 |  |
| 9 | 1.3.5 | Secure HVAC permit | milestone | 0d | 2016-09-26 | 2016-09-26 | 3 |  |  | 2016-09-26 | 2016-09-26 | 0d | 0.12d | 0d |  | General contractor; Permit |  |  | 2,000 | 2,000 |  |
| 10 | 1.3.6 | Secure miscellaneous permits | milestone | 0d | 2016-09-26 | 2016-09-26 | 3 |  |  | 2016-09-26 | 2016-09-26 | 0d | 0.12d | 0d |  | General contractor; Permit |  |  | 4,000 | 3,000 |  |
| 11 | 2 | **Site Work** |  | 2.75d | 2016-09-27 | 2016-09-29 |  |  |  | 2016-09-27 | 2016-09-29 | 2.75d | 0.12d |  |  |  | 30h |  | 2,900 | 2,900 |  |
| 12 | 2.1 | Clear site |  | 1d | 2016-09-27 | 2016-09-27 | 5, 6, 7, 8, 9, 10 |  |  | 2016-09-27 | 2016-09-27 | 1d | 0.12d | 0d |  | Site excavation contractor | 8h |  | 720 | 720 |  |
| 13 | 2.2 | Install temporary power service |  | 6h | 2016-09-28 | 2016-09-28 | 12 |  |  | 2016-09-28 | 2016-09-28 | 6h | 0.12d | 0d |  | Electric company | 6h |  | 900 | 900 |  |
| 14 | 2.3 | Install underground utilities |  | 1d | 2016-09-28 | 2016-09-29 | 13 |  |  | 2016-09-28 | 2016-09-29 | 1d | 0.12d | 0d |  | Electric contractor; Plumbing contractor | 16h |  | 1,280 | 1,280 |  |
| 15 | 3 | **Foundation** |  | 13.25d | 2016-09-29 | 2016-10-18 |  |  |  | 2016-09-29 | 2016-10-18 | 13.25d | 0d |  |  |  | 280h |  | 27,160 | 27,160 |  |
| 16 | 3.1 | Excavate for foundations |  | 3d | 2016-09-29 | 2016-10-04 | 14 |  |  | 2016-09-29 | 2016-10-04 | 3d | 0.12d | 0d |  | Site excavation contractor | 24h |  | 2,160 | 2,160 |  |
| 17 | 3.2 | Form basement walls |  | 13d | 2016-10-04 | 2016-10-08 | 16 |  |  | 2016-10-04 | 2016-10-08 | 13d | 0d |  |  | Concrete contractor | 104h |  | 8,320 | 8,320 |  |
| 18 | 3.3 | Pour concrete for foundations & basement walls |  | 12d | 2016-10-08 | 2016-10-12 | 17 |  |  | 2016-10-08 | 2016-10-12 | 12d | 0d |  |  | Concrete contractor | 96h |  | 7,680 | 7,680 |  |
| 19 | 3.4 | Strip basement wall forms |  | 2d | 2016-10-12 | 2016-10-13 | 18 |  |  | 2016-10-12 | 2016-10-13 | 2d | 0d |  |  | Concrete contractor | 16h |  | 1,280 | 1,280 |  |
| 20 | 3.5 | Waterproof/insulate basement walls |  | 2d | 2016-10-13 | 2016-10-14 | 19 |  |  | 2016-10-13 | 2016-10-14 | 2d | 0d |  |  | Concrete contractor | 16h |  | 1,280 | 1,280 |  |
| 21 | 3.6 | Perform foundation inspection |  | 1d | 2016-10-14 | 2016-10-14 | 20, 16 |  |  | 2016-10-14 | 2016-10-14 | 1d | 0d |  |  | Inspector | 8h |  | 5,000 | 5,000 |  |
| 22 | 3.7 | Backfill foundation |  | 2d | 2016-10-17 | 2016-10-18 | 21 |  |  | 2016-10-17 | 2016-10-18 | 2d | 0d |  |  | Site excavation contractor | 16h |  | 1,440 | 1,440 |  |
| 23 | 4 | **Framing** |  | 21.75d | 2016-10-19 | 2016-11-17 |  |  |  | 2016-10-19 | 2016-11-17 | 21.75d | 0d |  |  |  | 174h |  | 10,080 | 10,080 |  |
| 24 | 4.1 | Install 1st floor joists |  | 2d | 2016-10-19 | 2016-10-20 | 22 |  |  | 2016-10-19 | 2016-10-20 | 2d | 0d |  |  | Framing contractor | 16h |  | 960 | 960 |  |
| 25 | 4.2 | Lay 1st floor decking |  | 2d | 2016-10-21 | 2016-10-24 | 24 |  |  | 2016-10-21 | 2016-10-24 | 2d | 0d |  |  | Framing contractor | 16h |  | 960 | 960 |  |
| 26 | 4.3 | Frame 1st floor walls |  | 4d | 2016-10-25 | 2016-10-28 | 25 |  |  | 2016-10-25 | 2016-10-28 | 4d | 0d |  |  | Framing contractor | 32h |  | 1,920 | 1,920 |  |
| 27 | 4.4 | Frame 1st floor corners |  | 1d | 2016-10-31 | 2016-10-31 | 26 |  |  | 2016-10-31 | 2016-10-31 | 1d | 0d |  |  | Framing contractor | 8h |  | 480 | 480 |  |
| 28 | 4.5 | Install 2nd floor joists |  | 2d | 2016-11-01 | 2016-11-02 | 27 |  |  | 2016-11-01 | 2016-11-02 | 2d | 0d |  |  | Framing contractor | 16h |  | 960 | 960 |  |
| 29 | 4.6 | Frame 2nd floor decking |  | 2d | 2016-11-03 | 2016-11-04 | 28 |  |  | 2016-11-03 | 2016-11-04 | 2d | 0d |  |  | Framing contractor | 16h |  | 960 | 960 |  |
| 30 | 4.7 | Frame 2nd floor walls |  | 3d | 2016-11-07 | 2016-11-09 | 29 |  |  | 2016-11-07 | 2016-11-09 | 3d | 0d |  |  | Framing contractor | 24h |  | 1,440 | 1,440 |  |
| 31 | 4.8 | Frame 2nd floor corners |  | 2d | 2016-11-10 | 2016-11-11 | 30 |  |  | 2016-11-10 | 2016-11-11 | 2d | 0d |  |  | Framing contractor | 16h |  | 960 | 960 |  |
| 32 | 4.9 | Complete roof framing |  | 3d | 2016-11-14 | 2016-11-16 | 31 |  |  | 2016-11-14 | 2016-11-16 | 3d | 0d |  |  | Framing contractor | 24h |  | 1,440 | 1,440 |  |
| 33 | 4.10 | Conduct framing inspection |  | 6h | 2016-11-17 | 2016-11-17 | 32 |  |  | 2016-11-17 | 2016-11-17 | 6h | 0d |  |  | Inspector | 6h |  |  |  |  |

| ID | WBS | Task | Duration | Start | Finish | Predecessors | Baseline start | Baseline finish | Baseline duration | Total slack | Free slack | Resources | Work | Cost | Baseline cost |
| --- | --- | --- | --- | --- | --- | --- | --- | --- | --- | --- | --- | --- | --- | --- | --- |
| 34 | 5 | **Dry In** | 21.75d | 2016-11-17 | 2016-12-16 |  | 2016-11-17 | 2016-12-16 | 21.75d | 0d |  |  | 152h | 9,240 | 9,240 |
| 35 | 5.1 | Install 1st floor sheathing | 3d | 2016-11-17 | 2016-11-22 | 33 | 2016-11-17 | 2016-11-22 | 3d | 0d |  | Framing contractor | 24h | 1,440 | 1,440 |
| 36 | 5.2 | Install 2nd floor sheathing | 3d | 2016-11-22 | 2016-11-25 | 35 | 2016-11-22 | 2016-11-25 | 3d | 0d |  | Framing contractor | 24h | 1,440 | 1,440 |
| 37 | 5.3 | Install roof decking | 3d | 2016-11-17 | 2016-11-21 | 32 | 2016-11-17 | 2016-11-21 | 3d | 3.75d | 0d | Framing contractor | 24h | 1,440 | 1,440 |
| 38 | 5.4 | Install felt, flashing and shingles | 3d | 2016-12-02 | 2016-12-07 | 46 | 2016-12-02 | 2016-12-07 | 3d | 0d |  | Roofing contractor | 24h | 1,560 | 1,560 |
| 39 | 5.5 | Hang 1st floor exterior doors | 1d | 2016-12-07 | 2016-12-08 | 38 | 2016-12-07 | 2016-12-08 | 1d | 0d |  | Framing contractor | 8h | 480 | 480 |
| 40 | 5.6 | Install 1st floor windows | 3d | 2016-12-08 | 2016-12-13 | 39 | 2016-12-08 | 2016-12-13 | 3d | 0d |  | Framing contractor | 24h | 1,440 | 1,440 |
| 41 | 5.7 | Install 2nd floor windows | 3d | 2016-12-13 | 2016-12-16 | 40 | 2016-12-13 | 2016-12-16 | 3d | 0d |  | Framing contractor | 24h | 1,440 | 1,440 |
| 42 | 6 | **Exterior Finishes** | 13d | 2016-12-16 | 2017-01-04 |  | 2016-12-16 | 2017-01-04 | 13d | 12.25d |  |  | 104h | 6,240 | 6,240 |
| 43 | 6.1 | Complete exterior brick | 2w | 2016-12-16 | 2016-12-30 | 41 | 2016-12-16 | 2016-12-30 | 2w | 12.25d | 0d | Masonry contractor | 80h | 4,800 | 4,800 |
| 44 | 6.2 | Complete exterior siding | 3d | 2016-12-30 | 2017-01-04 | 43 | 2016-12-30 | 2017-01-04 | 3d | 12.25d | 0d | Framing contractor | 24h | 1,440 | 1,440 |
| 45 | 7 | **Utility Rough-Ins and Complete Concrete** | 13.75d | 2016-11-22 | 2016-12-09 |  | 2016-11-22 | 2016-12-09 | 13.75d | 3.75d |  |  | 224h | 15,640 | 15,640 |
| 46 | 7.1 | Rough-in plumbing | 5d | 2016-11-25 | 2016-12-02 | 37, 36 | 2016-11-25 | 2016-12-02 | 5d | 0d |  | Plumbing contractor | 40h | 3,200 | 3,200 |
| 47 | 7.2 | Conduct rough-in plumbing inspection | 1d | 2016-12-02 | 2016-12-05 | 46 | 2016-12-02 | 2016-12-05 | 1d | 20d | 0d | Inspector | 8h |  |  |
| 48 | 7.3 | Place concrete for basement floor | 2w | 2016-12-05 | 2016-12-08 | 47 | 2016-12-05 | 2016-12-08 | 2w | 40.25d |  | Concrete contractor | 80h | 6,400 | 6,400 |
| 49 | 7.4 | Rough-in electrical | 5d | 2016-11-25 | 2016-12-02 | 37, 36 | 2016-11-25 | 2016-12-02 | 5d | 6d | 0d | Electric contractor | 40h | 3,200 | 3,200 |
| 50 | 7.5 | Conduct rough-in electrical inspection | 1d | 2016-12-02 | 2016-12-05 | 49 | 2016-12-02 | 2016-12-05 | 1d | 6d | 0d | Inspector | 8h |  |  |
| 51 | 7.6 | Rough-in HVAC | 3d | 2016-12-05 | 2016-12-08 | 50 | 2016-12-05 | 2016-12-08 | 3d | 6d | 0d | Heating and AC contractor | 24h | 1,560 | 1,560 |
| 52 | 7.7 | Conduct rough-in HVAC inspection | 1d | 2016-12-08 | 2016-12-09 | 51 | 2016-12-08 | 2016-12-09 | 1d | 24d |  | Inspector | 8h |  |  |
| 53 | 7.8 | Rough-in communication - phone, cable, computer, alarm | 2d | 2016-11-22 | 2016-11-23 | 37 | 2016-11-22 | 2016-11-23 | 2d | 16.75d |  | Electric contractor | 16h | 1,280 | 1,280 |
| 54 | 8 | **Interior Finishes** | 30d | 2016-12-16 | 2017-01-27 |  | 2016-12-16 | 2017-01-27 | 30d | 0d |  |  | 408h | 64,360 | 64,360 |
| 55 | 8.1 | **Insulation** | 11d | 2016-12-16 | 2017-01-02 |  | 2016-12-16 | 2017-01-02 | 11d | 0d |  |  | 32h | 1,440 | 1,440 |
| 56 | 8.1.1 | Place wall insulation - 1st floor | 1d | 2016-12-16 | 2016-12-19 | 35, 41, 53, 51, 49, 36 | 2016-12-16 | 2016-12-19 | 1d | 0d |  | Insulation contractor | 8h | 480 | 480 |
| 57 | 8.1.2 | Place wall insulation - 2nd floor | 1d | 2016-12-19 | 2016-12-20 | 56 | 2016-12-19 | 2016-12-20 | 1d | 27d | 3d | Insulation contractor | 8h | 480 | 480 |
| 58 | 8.1.3 | Place ceiling insulation - 2nd floor | 1d | 2016-12-29 | 2016-12-30 | 64, 57 | 2016-12-29 | 2016-12-30 | 1d | 24d | 0d | Insulation contractor | 8h | 480 | 480 |
| 59 | 8.1.4 | Conduct insulation inspection | 1d | 2016-12-30 | 2017-01-02 | 58 | 2016-12-30 | 2017-01-02 | 1d | 24d |  | Inspector | 8h |  |  |

| ID | WBS | Task | Duration | Start | Finish | Predecessors | Baseline start | Baseline finish | Baseline duration | Total slack | Free slack | Resources | Work | Cost | Baseline cost |
| --- | --- | --- | --- | --- | --- | --- | --- | --- | --- | --- | --- | --- | --- | --- | --- |
| 60 | 8.2 | **Drywall** | 9d | 2016-12-19 | 2016-12-30 |  | 2016-12-19 | 2016-12-30 | 9d | 0d |  |  | 80h | 4,800 | 4,800 |
| 61 | 8.2.1 | Install drywall - 1st floor walls | 2d | 2016-12-19 | 2016-12-21 | 56 | 2016-12-19 | 2016-12-21 | 2d | 0d |  | Drywall contractor | 16h | 960 | 960 |
| 62 | 8.2.2 | Install drywall - 1st floor overhead | 2d | 2016-12-21 | 2016-12-23 | 61 | 2016-12-21 | 2016-12-23 | 2d | 0d |  | Drywall contractor | 16h | 960 | 960 |
| 63 | 8.2.3 | Install drywall 2nd floor walls | 2d | 2016-12-23 | 2016-12-27 | 62, 57 | 2016-12-23 | 2016-12-27 | 2d | 24d | 0d | Drywall contractor | 16h | 960 | 960 |
| 64 | 8.2.4 | Install drywall 2nd floor overhead | 2d | 2016-12-27 | 2016-12-29 | 63 | 2016-12-27 | 2016-12-29 | 2d | 24d | 0d | Drywall contractor | 16h | 960 | 960 |
| 65 | 8.2.5 | Tape and float 1st floor drywall | 1d | 2016-12-23 | 2016-12-26 | 62 | 2016-12-23 | 2016-12-26 | 1d | 0d |  | Drywall contractor | 8h | 480 | 480 |
| 66 | 8.2.6 | Tape and float 2nd floor drywall | 1d | 2016-12-29 | 2016-12-30 | 64, 65 | 2016-12-29 | 2016-12-30 | 1d | 32.5d |  | Drywall contractor | 8h | 480 | 480 |
| 67 | 8.3 | **Paint and Wallpaper** | 11d | 2016-12-26 | 2017-01-10 |  | 2016-12-26 | 2017-01-10 | 11d | 0d |  |  | 72h | 11,680 | 11,680 |
| 68 | 8.3.1 | Texture all except entry and kitchen - 1st floor | 1d | 2016-12-26 | 2016-12-27 | 65 | 2016-12-26 | 2016-12-27 | 1d | 0d |  | Painting contractor | 8h | 520 | 520 |
| 69 | 8.3.2 | Paint all except entry and kitchen - 1st floor | 1d | 2016-12-27 | 2016-12-28 | 68 | 2016-12-27 | 2016-12-28 | 1d | 0d |  | Painting contractor; Paint [100 Litres] | 8h | 2,520 | 2,520 |
| 70 | 8.3.3 | Hang wallpaper entry and kitchen - 1st floor | 1d | 2016-12-28 | 2016-12-29 | 69 | 2016-12-28 | 2016-12-29 | 1d | 0d |  | Painting contractor | 8h | 520 | 520 |
| 71 | 8.3.4 | Texture all - 2nd floor | 1d | 2016-12-27 | 2016-12-28 | 68 | 2016-12-27 | 2016-12-28 | 1d | 33.5d | 0d | Painting contractor | 8h | 520 | 520 |
| 72 | 8.3.5 | Paint all - 2nd floor | 1d | 2016-12-28 | 2016-12-29 | 71 | 2016-12-28 | 2016-12-29 | 1d | 33.5d |  | Painting contractor; Paint [100 Litres] | 8h | 2,520 | 2,520 |
| 73 | 8.3.6 | Paint exterior siding & trim work | 4d | 2017-01-04 | 2017-01-10 | 44 | 2017-01-04 | 2017-01-10 | 4d | 12.25d | 0d | Painting contractor; Paint [150 Litres] | 32h | 5,080 | 5,080 |
| 74 | 8.4 | **Cabinets** | 6d | 2016-12-29 | 2017-01-06 |  | 2016-12-29 | 2017-01-06 | 6d | 0d |  |  | 48h | 2,880 | 2,880 |
| 75 | 8.4.1 | Install 1st floor - kitchen cabinets | 2d | 2016-12-29 | 2017-01-02 | 70 | 2016-12-29 | 2017-01-02 | 2d | 0d |  | Finish carpentry contractor | 16h | 960 | 960 |
| 76 | 8.4.2 | Install 1st floor - master bath and guest cabinets | 1d | 2017-01-02 | 2017-01-03 | 75 | 2017-01-02 | 2017-01-03 | 1d | 0d |  | Finish carpentry contractor | 8h | 480 | 480 |
| 77 | 8.4.3 | Install 2nd floor - hall bath and private bath cabinets | 1d | 2017-01-03 | 2017-01-04 | 76 | 2017-01-03 | 2017-01-04 | 1d | 1d | 0d | Finish carpentry contractor | 8h | 480 | 480 |
| 78 | 8.4.4 | Install chair rails, crown moldings, trim | 2d | 2017-01-04 | 2017-01-06 | 77 | 2017-01-04 | 2017-01-06 | 2d | 20d |  | Finish carpentry contractor | 16h | 960 | 960 |
| 79 | 8.5 | **Finish Plumbing** | 6d | 2017-01-02 | 2017-01-10 |  | 2017-01-02 | 2017-01-10 | 6d | 0d |  |  | 48h | 3,200 | 3,200 |
| 80 | 8.5.1 | Complete 1st floor - kitchen plumbing | 1d | 2017-01-02 | 2017-01-03 | 75, 47 | 2017-01-02 | 2017-01-03 | 1d | 0d |  | Plumbing contractor | 8h | 640 | 640 |
| 81 | 8.5.2 | Complete 1st floor - master bath and guest plumbing | 2d | 2017-01-03 | 2017-01-05 | 80, 76 | 2017-01-03 | 2017-01-05 | 2d | 0d |  | Plumbing contractor | 16h | 1,280 | 1,280 |
| 82 | 8.5.3 | Complete 2nd floor - hall bath and private bath plumbing | 2d | 2017-01-05 | 2017-01-09 | 81, 77 | 2017-01-05 | 2017-01-09 | 2d | 0d |  | Plumbing contractor | 16h | 1,280 | 1,280 |
| 83 | 8.5.4 | Conduct finish plumbing inspection | 1d | 2017-01-09 | 2017-01-10 | 82 | 2017-01-09 | 2017-01-10 | 1d | 0d |  | Inspector | 8h |  |  |

| ID | WBS | Task | Duration | Start | Finish | Predecessors | Baseline start | Baseline finish | Baseline duration | Total slack | Free slack | Resources | Work | Cost | Baseline cost |
| --- | --- | --- | --- | --- | --- | --- | --- | --- | --- | --- | --- | --- | --- | --- | --- |
| 84 | 8.6 | **Finish Electrical** | 3d | 2017-01-09 | 2017-01-12 |  | 2017-01-09 | 2017-01-12 | 3d | 1d |  |  | 40h | 2,560 | 2,560 |
| 85 | 8.6.1 | Complete 1st floor circuits to service panel | 1d | 2017-01-09 | 2017-01-10 | 82, 50 | 2017-01-09 | 2017-01-10 | 1d | 3d | 0d | Electric contractor | 8h | 640 | 640 |
| 86 | 8.6.2 | Complete 2nd floor circuits to service panel | 1d | 2017-01-10 | 2017-01-11 | 85 | 2017-01-10 | 2017-01-11 | 1d | 3d | 0d | Electric contractor | 8h | 640 | 640 |
| 87 | 8.6.3 | Conduct finish electrical inspection | 1d | 2017-01-11 | 2017-01-12 | 86 | 2017-01-11 | 2017-01-12 | 1d | 3d |  | Inspector | 8h |  |  |
| 88 | 8.6.4 | Complete communications wiring - phone, cable, computer, alarm | 2d | 2017-01-10 | 2017-01-12 | 83 | 2017-01-10 | 2017-01-12 | 2d | 0d |  | Electric contractor | 16h | 1,280 | 1,280 |
| 89 | 8.7 | **Finish HVAC** | 3d | 2017-01-12 | 2017-01-17 |  | 2017-01-12 | 2017-01-17 | 3d | 0d |  |  | 24h | 1,040 | 1,040 |
| 90 | 8.7.1 | Complete 1st floor - zone 1 HVAC | 1d | 2017-01-12 | 2017-01-13 | 88, 52 | 2017-01-12 | 2017-01-13 | 1d | 0d |  | Heating and AC contractor | 8h | 520 | 520 |
| 91 | 8.7.2 | Complete 2nd floor - zone 2 HVAC | 1d | 2017-01-13 | 2017-01-16 | 90 | 2017-01-13 | 2017-01-16 | 1d | 0d |  | Heating and AC contractor | 8h | 520 | 520 |
| 92 | 8.7.3 | Conduct HVAC inspection | 1d | 2017-01-16 | 2017-01-17 | 91 | 2017-01-16 | 2017-01-17 | 1d | 0d |  | Inspector | 8h |  |  |
| 93 | 8.8 | **Carpet, Tile and Appliances** | 8d | 2017-01-17 | 2017-01-27 |  | 2017-01-17 | 2017-01-27 | 8d | 0d |  |  | 64h | 36,760 | 36,760 |
| 94 | 8.8.1 | Tile entry, kitchen and baths | 3d | 2017-01-17 | 2017-01-20 | 87, 92 | 2017-01-17 | 2017-01-20 | 3d | 0d |  | Flooring contractor | 24h | 1,680 | 1,680 |
| 95 | 8.8.2 | Carpet 1st floor | 2d | 2017-01-20 | 2017-01-24 | 94 | 2017-01-20 | 2017-01-24 | 2d | 0d |  | Flooring contractor; Carpet [200 Sq Metres] | 16h | 17,320 | 17,320 |
| 96 | 8.8.3 | Carpet 2nd floor | 2d | 2017-01-24 | 2017-01-26 | 95 | 2017-01-24 | 2017-01-26 | 2d | 0d |  | Flooring contractor; Carpet [200 Sq Metres] | 16h | 17,320 | 17,320 |
| 97 | 8.8.4 | Install appliances | 1d | 2017-01-26 | 2017-01-27 | 96 | 2017-01-26 | 2017-01-27 | 1d | 0d |  | Appliance contractor | 8h | 440 | 440 |
| 98 | 9 | **Landscaping and Grounds Work** | 18d | 2017-01-10 | 2017-02-03 |  | 2017-01-10 | 2017-02-03 | 18d | 0d |  |  | 56h | 3,840 | 3,840 |
| 99 | 9.1 | Pour concrete driveway and sidewalks | 2d | 2017-01-10 | 2017-01-11 | 73 | 2017-01-10 | 2017-01-11 | 2d | 12.25d |  | Concrete contractor | 16h | 1,360 | 1,360 |
| 100 | 9.2 | Install backyard fence | 2d | 2017-01-27 | 2017-01-31 | 97, 99 | 2017-01-27 | 2017-01-31 | 2d | 0d |  | Fencing contractor | 16h | 1,040 | 1,040 |
| 101 | 9.3 | Sod and complete plantings - front yard | 2d | 2017-01-31 | 2017-02-02 | 100 | 2017-01-31 | 2017-02-02 | 2d | 0d |  | Landscape contractor | 16h | 960 | 960 |
| 102 | 9.4 | Sod and complete plantings - backyard | 1d | 2017-02-02 | 2017-02-03 | 101 | 2017-02-02 | 2017-02-03 | 1d | 0d |  | Landscape contractor | 8h | 480 | 480 |
| 103 | 10 | **Final Acceptance** | 7.5d | 2017-02-03 | 2017-02-15 |  | 2017-02-03 | 2017-02-14 | 7.25d | 0d |  |  | 62h | 2,450 | 2,450 |
| 104 | 10.1 | Complete final inspection for certificate of occupancy | 6h | 2017-02-03 | 2017-02-06 | 102, 92, 87, 83, 59, 78, 48 | 2017-02-03 | 2017-02-06 | 6h | 0d |  | Inspector | 6h |  |  |
| 105 | 10.2 | Cleanup for occupancy | 1d | 2017-02-06 | 2017-02-07 | 97, 104 | 2017-02-06 | 2017-02-07 | 1d | 0d |  | Maid service | 8h | 450 | 450 |
| 106 | 10.3 | Perform final walk-through inspection | 1d | 2017-02-07 | 2017-02-08 | 105 | 2017-02-07 | 2017-02-08 | 1d | 0d |  | Owner | 8h |  |  |
| 107 | 10.4 | Complete punch list items | 5d | 2017-02-08 | 2017-02-15 | 106FS-2.5% | 2017-02-08 | 2017-02-14 | 5d | 0d |  | General contractor | 40h | 2,000 | 2,000 |
